# CONTRACTSCHEMA kantoorgebouw

Schedule from MS Project, 2004-05-31 to 2005-07-22, A marks actual dates.
BAM Nelissen Van Egteren

## Calendars

- Standaard: Mon-Fri 08:30-12:30, 13:00-17:00; Sat-Sun off.

## Schedule

| ID | WBS | Task | Type | Duration | Start | Finish | Predecessors | Complete | Remaining | Total slack | Free slack | Constraint | Text1 |
| --- | --- | --- | --- | --- | --- | --- | --- | --- | --- | --- | --- | --- | --- |
| 1 | 1 | **AANLOOP FASE** |  | 20d? | 2004-05-31 | 2004-06-25 |  |  |  | 280d |  |  |  |
| 2 | 1.1 | bouwplaats inrichten |  | 1.8w? | 2004-05-31 | 2004-06-10 |  |  |  | 185d |  |  |  |
| 3 | 1.2 | bouwput ontgraven |  | 1w? | 2004-06-07 | 2004-06-11 |  |  |  | 174d | 0d | finish no earlier than 2004-06-11 |  |
| 4 | 1.3 | paalfundatie heien |  | 2w? | 2004-06-14 | 2004-06-25 |  |  |  | 279d |  | start no earlier than 2004-06-14 |  |
| 5 | 2 | **ONDERBOUW FASE** |  | 18d? | 2004-06-23 | 2004-07-16 |  |  |  | 265d |  |  |  |
| 6 | 2.1 | funderingsbalken+poeren |  | 2.4w? | 2004-06-23 | 2004-07-08 |  |  |  | 271d |  | finish no earlier than 2004-07-08 |  |
| 7 | 2.2 | beg.grond vloer |  | 1.8w? | 2004-07-06 | 2004-07-16 |  |  |  | 265d |  | finish no earlier than 2004-07-16 | beg.gr.vloer |
| 8 | 3 | **BOVENBOUWFASE** |  | 113d? | 2004-07-14 A | 2004-12-17 |  |  | 113d? | 155d |  |  |  |
| 9 | 3.1 | vertikale constructie beg.gr |  | 7.6w? | 2004-07-14 | 2004-09-03 |  |  |  | 230d |  | finish no earlier than 2004-09-03 | beg.grond |
| 10 | 3.2 | 1e verd. insitu betonvloer |  | 4.2w? | 2004-08-12 | 2004-09-09 |  |  |  | 226d |  | start no earlier than 2004-08-12 | 1e verd,vloer |
| 11 | 3.3 | 1e verdiepingsvloer gestort | milestone | 0w | 2004-09-09 A | 2004-09-09 A | 10 | 100% |  |  |  |  |  |
| 12 | 3.4 | vertikale constructie 1e verd. |  | 3.6w? | 2004-08-26 | 2004-09-20 |  |  |  | 219d |  | finish no earlier than 2004-09-20 | 1e verd |
| 13 | 3.5 | 2e verd. insitu betonvloer |  | 4w? | 2004-09-06 | 2004-10-01 |  |  |  | 210d |  | start no earlier than 2004-09-06 | 2e verd.vloer |
| 14 | 3.6 | 2e verdiepingsvloer gestort | milestone | 0w | 2004-10-01 A | 2004-10-01 A | 13 | 100% |  |  |  |  |  |
| 15 | 3.7 | vertikale constructie 2e verd. |  | 3.6w? | 2004-09-17 | 2004-10-12 |  |  |  | 203d |  | finish no earlier than 2004-10-12 | 2e verd |
| 16 | 3.8 | 3e verd, insitu betonvloer |  | 4.2w? | 2004-09-28 | 2004-10-26 |  |  |  | 193d |  | start no earlier than 2004-09-28 | 3e verd,vloer |
| 17 | 3.9 | 3e verdiepingsvloer gestort | milestone | 0w | 2004-10-26 A | 2004-10-26 A | 16 | 100% |  |  |  |  |  |
| 18 | 3.10 | vertikale constructie 3e verd. |  | 3.8w? | 2004-10-11 | 2004-11-04 |  |  |  | 186d |  | finish no earlier than 2004-11-04 | 3e verd |
| 19 | 3.11 | 4e verd. insitu betonvloer |  | 4.6w? | 2004-10-20 | 2004-11-19 |  |  |  | 175d |  | start no earlier than 2004-10-20 | 4e verd,vloer |
| 20 | 3.12 | 4e verdiepingsvloer gestort | milestone | 0w | 2004-11-19 A | 2004-11-19 A | 19 | 100% |  |  |  |  |  |
| 21 | 3.13 | vertikale constructie 4e verd. |  | 4w? | 2004-11-04 | 2004-12-01 |  |  |  | 167d |  | finish no earlier than 2004-12-01 | 4e verd |
| 22 | 3.14 | dakvloer insitu betonvloer |  | 5w? | 2004-11-15 | 2004-12-17 |  |  |  | 155d |  | start no earlier than 2004-11-15 | dakvloer |
| 23 | 3.15 | dakvloer gestort | milestone | 0w | 2004-12-17 A | 2004-12-17 A | 22 | 100% |  |  |  |  |  |
| 25 | 4 | **GEVEL/DAK FASE** |  | 88d? | 2004-11-30 | 2005-03-31 |  |  |  | 81d |  |  |  |
| 26 | 4.1 | dakopbouw |  | 6.2w? | 2004-12-10 | 2005-01-21 |  |  |  | 130d |  | finish no earlier than 2005-01-21 |  |
| 27 | 4.2 | dakbedekking |  | 6.2w? | 2004-12-10 | 2005-01-21 |  |  |  | 130d |  | finish no earlier than 2005-01-21 |  |
| 28 | 4.3 | metselgevel linkervleugel |  | 12.6w? | 2004-11-30 | 2005-02-24 |  |  |  | 106d | 0d | finish no earlier than 2005-02-24 | linkervleugel |
| 29 | 4.4 | linkervleugel waterdicht | milestone | 0w | 2005-02-25 | 2005-02-25 | 28 |  |  | 106d |  | start no earlier than 2005-02-25 |  |
| 30 | 4.5 | metselgevel rechtervleugel |  | 6.6w? | 2005-02-15 | 2005-03-31 |  |  |  | 81d | 0d | finish no earlier than 2005-03-31 | rechtervleugel |
| 31 | 4.6 | rechtervleugel waterdicht | milestone | 0w | 2005-03-31 | 2005-03-31 | 30 |  |  | 81d |  |  |  |

| ID | WBS | Task | Duration | Start | Finish | Total slack | Constraint | Text1 |
| --- | --- | --- | --- | --- | --- | --- | --- | --- |
| 32 | 5 | **AFBOUW LINKERVLEUGEL** | 76d? | 2005-03-01 | 2005-06-14 | 28d |  |  |
| 33 | 5.1 | **inbouwfase** | 42d? | 2005-03-01 | 2005-04-27 | 62d |  |  |
| 34 | 5.1.1 | cementdekvloer | 3.8w? | 2005-03-01 | 2005-03-25 | 85d | finish no earlier than 2005-03-25 | linkervleugel |
| 35 | 5.1.2 | binnenwanden | 7.2w? | 2005-03-09 | 2005-04-27 | 62d | finish no earlier than 2005-04-27 |  |
| 36 | 5.2 | **afwerkingsfase** | 49d? | 2005-03-29 | 2005-06-03 | 35d |  |  |
| 37 | 5.2.1 | plafond afwerking | 6.8w? | 2005-03-29 | 2005-05-13 | 50d | finish no earlier than 2005-05-13 | linkervleugel |
| 38 | 5.2.2 | wand afwerking | 6.8w? | 2005-04-12 | 2005-05-27 | 40d | finish no earlier than 2005-05-27 |  |
| 39 | 5.2.3 | vloer afwerking | 5.8w? | 2005-04-26 | 2005-06-03 | 35d | finish no earlier than 2005-06-03 |  |
| 40 | 5.3 | **uitrustingsfase** | 31d? | 2005-05-03 | 2005-06-14 | 28d |  |  |
| 41 | 5.3.1 | bouwkundige afmontage | 6.2w? | 2005-05-03 | 2005-06-14 | 28d | start no earlier than 2005-05-03 | linkervleugel |
| 42 | 5.3.2 | installatie afmontage | 6.2w? | 2005-05-03 | 2005-06-14 | 28d | finish no earlier than 2005-06-14 |  |
| 43 | 6 | **AFBOUW RECHTERVLEUGEL** | 75d? | 2005-04-04 | 2005-07-15 | 5d |  |  |
| 44 | 6.1 | **inbouwfase** | 47d? | 2005-04-04 | 2005-06-07 | 33d |  |  |
| 45 | 6.1.1 | cementdekvloer | 4.4w? | 2005-04-04 | 2005-05-03 | 58d | finish no earlier than 2005-05-03 | rechtervleugel |
| 46 | 6.1.2 | binnenwanden | 7.2w? | 2005-04-19 | 2005-06-07 | 33d | finish no earlier than 2005-06-07 |  |
| 47 | 6.2 | **afwerkingsfase** | 46d? | 2005-05-10 | 2005-07-12 | 8d |  |  |
| 48 | 6.2.1 | plafond afwerking | 6.4w? | 2005-05-10 | 2005-06-22 | 22d | finish no earlier than 2005-06-22 | rechtervleugel |
| 49 | 6.2.2 | wand afwerking | 6.8w? | 2005-05-19 | 2005-07-05 | 13d | finish no earlier than 2005-07-05 |  |
| 50 | 6.2.3 | vloer afwerking | 5.4w? | 2005-06-06 | 2005-07-12 | 8d | finish no earlier than 2005-07-12 |  |
| 51 | 6.3 | **uitrustingsfase** | 25d? | 2005-06-13 | 2005-07-15 | 5d |  |  |
| 52 | 6.3.1 | bouwkundige afmontage | 5w? | 2005-06-13 | 2005-07-15 | 5d | finish no earlier than 2005-07-15 | rechtervleugel |
| 53 | 6.3.2 | installatie afmontage | 5w? | 2005-06-13 | 2005-07-15 | 5d | finish no earlier than 2005-07-15 |  |
| 54 | 7 | **AFBOUW KERNGEBIED** | 39d? | 2005-05-24 | 2005-07-15 | 5d |  |  |
| 55 | 7.1 | toiletgroep | 7.8w? | 2005-05-24 | 2005-07-15 | 5d | finish no earlier than 2005-07-15 |  |
| 56 | 7.2 | trappenhuis | 7.8w? | 2005-05-24 | 2005-07-15 | 5d | finish no earlier than 2005-07-15 |  |

| ID | WBS | Task | Type | Duration | Start | Finish | Predecessors | Total slack | Constraint |
| --- | --- | --- | --- | --- | --- | --- | --- | --- | --- |
| 57 | 8 | **OPLEVERINGS FASE** |  | 28d? | 2005-06-15 | 2005-07-22 |  | 0d |  |
| 58 | 8.1 | opnemen bouw+installatie |  | 4.6w? | 2005-06-15 | 2005-07-15 |  | 5d | finish no earlier than 2005-07-15 |
| 59 | 8.2 | narooien gebouw |  | 3w? | 2005-07-04 | 2005-07-22 |  | 0d | finish no earlier than 2005-07-22 |
| 60 | 8.3 | opleveren gebouw | milestone | 0w | 2005-07-22 | 2005-07-22 | 59 | 0d |  |
